# Proyecto CRM - Corporacion Union

Schedule from MS Project, 2006-11-20 to 2006-12-26.

## Calendars

- Estándar: Mon-Fri 08:00-12:00, 13:00-17:00; Sat-Sun off. Exceptions (off unless hours are given): 2006-12-25.

## Resources

| Resource |
| --- |
| GP |
| R1 |
| D1 |
| LR |
| OP |

## Schedule

| ID | WBS | Task | Type | Duration | Start | Finish | Predecessors | Total slack | Free slack | Constraint | Resources | Work |
| --- | --- | --- | --- | --- | --- | --- | --- | --- | --- | --- | --- | --- |
| 1 | 1 | **Proyecto Laboratorio Clinilab** |  | 25.38d | 2006-11-20 08:00 | 2006-12-26 11:00 |  | 0d |  |  |  | 90h |
| 2 | 1.1 | Reunión de Arranque |  | 0.12d | 2006-11-20 08:00 | 2006-11-20 09:00 |  | 27.62d | 0d | start no earlier than 2006-11-20 08:00 | GP; D1 | 2h |
| 3 | 1.2 | Análsis y preparación material para definición requerimientos |  | 0.12d | 2006-11-20 09:00 | 2006-11-20 10:00 | 2 | 27.62d |  | start no earlier than 2006-11-20 08:00 | GP | 1h |
| 4 | 1.3 | **Especificación de Requerimientos** |  | 10d | 2006-11-23 08:00 | 2006-12-07 08:00 |  | 2d |  |  |  | 11h |
| 5 | 1.3.1 | **Levantamiento de Información** |  | 3.25d | 2006-11-23 08:00 | 2006-11-28 10:00 |  | 6.38d |  |  |  | 8h |
| 6 | 1.3.1.1 | Mesa de Trabajo #1 |  | 0.25d | 2006-11-23 08:00 | 2006-11-23 10:00 |  | 36.75d |  | start no earlier than 2006-11-23 08:00 | D1; GP | 4h |
| 7 | 1.3.1.2 | Mesa de Trabajo #2 |  | 0.25d | 2006-11-28 08:00 | 2006-11-28 10:00 |  | 28.88d | 0.75d | start no earlier than 2006-11-28 08:00 | GP; R1 | 4h |
| 8 | 1.3.2 | Elaboración del Informe Especificación de Req. |  | 0.25d | 2006-11-29 08:00 | 2006-11-29 10:00 | 7 | 59.5d | 1.75d | start no earlier than 2006-11-29 08:00 | GP | 2h |
| 9 | 1.3.3 | Entrega al Equipo de Proyecto Clinilab para su revisión | milestone | 0d | 2006-12-01 08:00 | 2006-12-01 08:00 | 8 | 0d |  | start no earlier than 2006-12-01 08:00 |  |  |
| 10 | 1.3.4 | Revisión por parte del Equipo de Proyecto Clinilab |  | 3d | 2006-12-01 08:00 | 2006-12-05 17:00 | 9 | 0d |  |  |  |  |
| 11 | 1.3.5 | Recepción de ajustes recomendados al Informe | milestone | 0d | 2006-12-05 17:00 | 2006-12-05 17:00 | 10 | 0d |  |  |  |  |
| 12 | 1.3.6 | Ajustes al Informe Especificación de Requerimientos |  | 1d | 2006-12-06 08:00 | 2006-12-06 17:00 | 11 | 0d |  |  |  | 1h |
| 13 | 1.3.7 | Entrega de Especificación de Req. para aprobación | milestone | 0d | 2006-12-07 08:00 | 2006-12-07 08:00 | 12 | 0d |  | start no earlier than 2006-12-07 08:00 |  |  |
| 14 | 1.3.8 | Aprobación del Informe Especificación de Requerimientos | milestone | 0d | 2006-12-07 08:00 | 2006-12-07 08:00 | 13 | 0d |  | start no earlier than 2006-09-15 08:00 |  |  |
| 15 | 1.3.9 | Informe Especificación de Requerimientos Aprobado | milestone | 0d | 2006-12-07 08:00 | 2006-12-07 08:00 | 14 | 0d |  |  |  |  |
| 16 | 1.4 | **Configuración y Desarrollo** |  | 15.38d | 2006-11-20 08:00 | 2006-12-11 11:00 |  | 0d |  |  |  | 55h |
| 17 | 1.4.1 | Creación estructura WiB3 para la Página Web |  | 0.12d | 2006-11-20 08:00 | 2006-11-20 09:00 |  | 39.88d |  | start no earlier than 2006-11-20 08:00 | OP | 1h |
| 18 | 1.4.2 | Creación de aplicaciones en N2C |  | 0.12d | 2006-11-20 08:00 | 2006-11-20 09:00 |  | 38.62d | 0d | start no earlier than 2006-11-20 08:00 | OP | 1h |
| 19 | 1.4.3 | **Diseño Gráfico** |  | 7.75d | 2006-11-23 10:00 | 2006-12-04 17:00 |  | 5.25d |  |  |  | 34h |
| 20 | 1.4.3.1 | Elaboración propuesta de diseño |  | 1.25d | 2006-11-23 10:00 | 2006-11-24 12:00 | 6 | 10.88d | 0d |  | D1 | 10h |
| 21 | 1.4.3.2 | Presentación al Cliente | milestone | 0d | 2006-11-24 12:00 | 2006-11-24 12:00 | 20 | 10.88d |  |  | D1 |  |
| 22 | 1.4.3.3 | Aprobación por parte del Cliente | milestone | 0d | 2006-11-30 08:00 | 2006-11-30 08:00 |  | 4.38d | 0d | start no earlier than 2006-11-30 08:00 |  |  |
| 23 | 1.4.3.4 | Configuración diseño en WiB3 |  | 3d | 2006-11-30 08:00 | 2006-12-04 17:00 | 22 | 4.38d |  |  | D1 | 24h |
| 24 | 1.4.4 | **Configuración Nuevas Aplicaciones** |  | 2.38d | 2006-12-07 08:00 | 2006-12-11 11:00 |  | 0d |  |  |  | 19h |
| 25 | 1.4.4.1 | Directorio de Clientes |  | 0.5d | 2006-12-07 08:00 | 2006-12-07 12:00 | 15 | 0d |  | start no earlier than 2006-12-07 08:00 | R1 | 4h |
| 26 | 1.4.4.2 | Funcionalidad para publicación de resultados |  | 0.12d | 2006-12-07 13:00 | 2006-12-07 14:00 | 25 | 0d |  |  | R1 | 1h |
| 27 | 1.4.4.3 | Reportes |  | 0.62d | 2006-12-07 14:00 | 2006-12-08 10:00 | 26 | 0d |  | start no earlier than 2006-01-31 08:00 | R1 | 5h |
| 28 | 1.4.4.4 | Estados de Cuenta - Facturación |  | 1d | 2006-12-08 10:00 | 2006-12-11 10:00 | 27 | 0d |  | start no earlier than 2006-08-21 08:00 | R1 | 8h |
| 29 | 1.4.4.5 | Pruebas internas |  | 0.12d | 2006-12-11 10:00 | 2006-12-11 11:00 | 28 | 0d |  |  | GP | 1h |
| 30 | 1.5 | Funcionalidades de la Página Web Configuradas | milestone | 0d | 2006-12-19 08:00 | 2006-12-19 08:00 |  | 8.75d | 3d | start no earlier than 2006-12-19 08:00 |  |  |

Notes:
- 18: esto es la creación de las Aplicaciones por parte de Aron
- 25: Se tomó en cuenta los días de ausencia de Andrey por Graduación

| ID | WBS | Task | Type | Duration | Start | Finish | Predecessors | Total slack | Free slack | Constraint | Resources | Work |
| --- | --- | --- | --- | --- | --- | --- | --- | --- | --- | --- | --- | --- |
| 31 | 1.6 | **Plan de Pruebas** |  | 0.25d | 2006-12-19 08:00 | 2006-12-19 10:00 |  | 5d |  |  |  | 1h |
| 32 | 1.6.1 | Elaboración Plan de Pruebas |  | 0.25d | 2006-12-19 08:00 | 2006-12-19 10:00 | 15 | 18.75d |  | start no earlier than 2006-12-19 08:00 | GP [50%] | 1h |
| 33 | 1.7 | Plan de Pruebas elaborado | milestone | 0d | 2006-11-20 08:00 | 2006-11-20 08:00 |  | 27.88d |  |  |  |  |
| 34 | 1.8 | **Pruebas de Certificación** |  | 0.62d | 2006-12-22 08:00 | 2006-12-22 14:00 |  | 0.62d |  |  |  | 5h |
| 35 | 1.8.1 | Preparación para las pruebas en ambiente de desarrollo |  | 0.12d | 2006-12-22 08:00 | 2006-12-22 09:00 | 30 | 0.62d | 0d | start no earlier than 2006-12-22 08:00 | GP | 1h |
| 36 | 1.8.2 | Realización de Pruebas de Funcionalidad (Cliente) | milestone | 0d | 2006-12-22 09:00 | 2006-12-22 09:00 | 35 | 0.62d | 0d | start no earlier than 2005-07-12 08:00 |  |  |
| 37 | 1.8.3 | Realización de Ajustes recomendados |  | 0.5d | 2006-12-22 09:00 | 2006-12-22 14:00 | 36 | 0.62d | 0d |  | R1 | 4h |
| 38 | 1.9 | Pruebas Certificadas | milestone | 0d | 2006-12-22 14:00 | 2006-12-22 14:00 | 37 | 0.62d | 0d |  |  |  |
| 39 | 1.10 | Adiestramiento |  | 0.5d | 2006-12-19 08:00 | 2006-12-19 12:00 | 30 | 4.75d |  |  | GP [50%]; D1 [50%] | 4h |
| 40 | 1.11 | **Puesta en Producción** |  | 0d | 2006-12-22 14:00 | 2006-12-22 14:00 |  | 0.62d |  |  |  |  |
| 41 | 1.11.1 | Migración de aplicaciones | milestone | 0d | 2006-12-22 14:00 | 2006-12-22 14:00 | 38 | 0.62d | 0d |  | OP [25%] |  |
| 42 | 1.11.2 | Pruebas integrales | milestone | 0d | 2006-12-22 14:00 | 2006-12-22 14:00 | 41 | 0.62d | 0d |  | GP [12.5%] |  |
| 43 | 1.12 | **Gerencia de Proyecto** |  | 25.25d | 2006-11-20 09:00 | 2006-12-26 11:00 |  | 0d |  |  |  | 10h |
| 44 | 1.12.1 | Planificación |  | 13d | 2006-11-20 09:00 | 2006-12-07 09:00 | 2 | 13.13d |  | start no earlier than 2006-11-16 08:00 | GP [1.9%] | 2h |
| 45 | 1.12.2 | Control y Seguimiento |  | 10d | 2006-12-11 11:00 | 2006-12-26 11:00 | 16 | 0d |  | start no earlier than 2006-12-01 08:00 | GP [10%] | 8h |
| 46 | 1.13 | Cierre |  | 0.13d | 2006-12-22 14:00 | 2006-12-22 15:02 | 42 | 0.62d |  |  | GP [96.2%] | 1h |

Notes:
- 40: Esta tarea no tiene duración porque se asume que se está desarrollando en el servidor N2C - ambiente de producción.
